# Kitchen Remodel

Schedule from Planner, 2003-12-28 to 2004-05-10.
Imendio
Phase: Initiation

## Calendars

- Default: Mon-Fri 08:00-12:00, 13:00-17:00; Sat-Sun off.

## Resources

| Resource | Rate |
| --- | --- |
| Town Engineer |  |
| Architect | 100 |
| Menard Construction | 100 |
| Sue Maute |  |
| Kurt Maute |  |

## Schedule

| ID | WBS | Task | Type | Duration | Start | Finish | Predecessors | Resources | Work | Best-Case | Worst-Case |
| --- | --- | --- | --- | --- | --- | --- | --- | --- | --- | --- | --- |
| 1 | 1 | **Initiation** |  |  | 2003-12-28 | 2004-01-11 |  |  | 80h | 0 | 0 |
| 2 | 1.1 | Define Objectives |  |  | 2003-12-28 | 2004-01-02 |  | Sue Maute; Kurt Maute | 80h | 0 | 0 |
| 3 | 1.2 | Return on Investment Analysis |  |  | 2004-01-02 | 2004-01-09 | 2 | Kurt Maute | 40h | 0 | 0 |
| 4 | 1.3 | Go/No-Go Decision | milestone | 0d | 2004-01-11 | 2004-01-11 | 3FS+40h | Sue Maute; Kurt Maute |  | 0 | 0 |
| 5 | 2 | **Planning** |  |  | 2004-01-11 | 2004-02-20 | 1 |  | 240h | 0 | 0 |
| 6 | 2.1 | **Scope** |  |  | 2004-01-11 | 2004-01-30 |  |  | 120h | 0 | 0 |
| 7 | 2.1.1 | Design Layout |  |  | 2004-01-11 | 2004-01-30 |  | Architect | 120h | 0 | 0 |
| 8 | 2.1.2 | Research & Choose Appliances |  |  | 2004-01-11 | 2004-01-30 |  | Sue Maute | 120h | 0 | 0 |
| 9 | 2.1.3 | Electrical Design |  |  | 2004-01-11 | 2004-01-30 |  | Architect | 120h | 0 | 0 |
| 10 | 2.1.4 | Plumbing Design |  |  | 2004-01-11 | 2004-01-30 |  | Architect | 120h | 0 | 0 |
| 11 | 2.2 | Create Schedule |  |  | 2004-01-30 | 2004-02-06 | 6 | Kurt Maute | 40h | 0 | 0 |
| 12 | 2.3 | Estimate Cost |  |  | 2004-01-30 | 2004-02-06 | 6 | Kurt Maute | 40h | 0 | 0 |
| 13 | 2.4 | Obtain Permits |  |  | 2004-01-30 | 2004-02-20 | 6 | Kurt Maute | 120h | 0 | 0 |
| 14 | 3 | **Execution** |  |  | 2004-02-20 | 2004-04-16 | 5 |  | 320h | 0 | 0 |
| 15 | 3.1 | Demolition |  |  | 2004-02-20 | 2004-03-05 |  | Menard Construction | 80h | 0 | 0 |
| 16 | 3.2 | Construction |  |  | 2004-03-05 | 2004-04-02 | 15 | Menard Construction | 160h | 0 | 0 |
| 17 | 3.3 | Final Inspection |  |  | 2004-04-02 | 2004-04-16 | 16 | Town Engineer | 80h | 0 | 0 |
| 18 | 4 | **Closure** |  |  | 2004-04-16 | 2004-05-10 | 14 |  | 124h | 0 | 0 |
| 19 | 4.1 | Lessons Learned |  |  | 2004-04-16 | 2004-04-23 |  | Kurt Maute | 40h | 0 | 0 |
| 20 | 4.2 | Pay all Vendors |  |  | 2004-04-16 | 2004-05-07 |  | Sue Maute | 120h | 0 | 0 |
| 21 | 4.3 | Have a Party |  |  | 2004-05-07 | 2004-05-10 | 20 | Sue Maute; Kurt Maute | 8h | 0 | 0 |

Notes:
- 16: Thu 01 Apr 2004, 08:18 Need confirmaiton of availability / on scheduled date - KMM
