# Sample 1

Schedule from Planner, 2004-07-01 to 2004-08-24.
Planner Community
Phase: Implementation

## Calendars

- Default: Mon-Fri 08:00-12:00, 13:00-17:00; Sat-Sun off.

## Resources

| Resource |
| --- |
| Alvaro del Castillo |
| Richard Hult |
| Mikael Hallendal |
| Lincoln Phipps |

## Schedule

| ID | WBS | Task | Type | Duration | Start | Finish | Predecessors | Resources | Work |
| --- | --- | --- | --- | --- | --- | --- | --- | --- | --- |
| 1 | 1 | **Project X** |  |  | 2004-07-01 | 2004-08-24 |  |  | 310.67h |
| 2 | 1.1 | Analysis |  |  | 2004-07-01 | 2004-07-08 |  | Alvaro del Castillo [75%] | 32h |
| 3 | 1.2 | Report | milestone | 0d | 2004-07-08 | 2004-07-08 | 2 |  |  |
| 4 | 1.3 | **Prototype** |  |  | 2004-07-08 | 2004-07-15 | 3 |  | 40h |
| 5 | 1.3.1 | Design prototype |  |  | 2004-07-08 | 2004-07-13 |  | Richard Hult | 24h |
| 6 | 1.3.2 | Implementation |  |  | 2004-07-08 | 2004-07-14 |  | Richard Hult [25%]; Mikael Hallendal | 40h |
| 7 | 1.3.3 | Evaluation |  |  | 2004-07-14 | 2004-07-15 | 6 |  | 8h |
| 8 | 1.3.4 | Report | milestone | 0d | 2004-07-15 | 2004-07-15 | 7 |  |  |
| 9 | 1.4 | **Product** |  |  | 2004-07-15 | 2004-08-24 | 8 |  | 228h |
| 10 | 1.4.1 | Summarize issues |  |  | 2004-07-15 | 2004-07-16 |  | Richard Hult; Mikael Hallendal | 24h |
| 11 | 1.4.2 | Finalize design |  |  | 2004-07-16 | 2004-07-23 | 10 | Richard Hult | 40h |
| 12 | 1.4.3 | **Implementation** |  |  | 2004-07-23 | 2004-08-13 | 11 |  | 120h |
| 13 | 1.4.3.1 | Back-end |  |  | 2004-07-23 | 2004-08-13 |  | Richard Hult | 120h |
| 14 | 1.4.3.2 | Front-end |  |  | 2004-07-23 | 2004-08-13 |  | Mikael Hallendal | 120h |
| 15 | 1.4.4 | Evaluation |  |  | 2004-08-13 | 2004-08-17 | 12 | Alvaro del Castillo | 16h |
| 16 | 1.4.5 | QA |  |  | 2004-08-17 | 2004-08-24 | 15 | Lincoln Phipps | 40h |
| 17 | 1.4.6 | Report | milestone | 0d | 2004-08-24 | 2004-08-24 | 16 |  |  |
